# PROYECTO ELÉCTRICO

Schedule from MS Project, 2020-10-15 to 2021-04-14, status date 2020-12-09, A marks actual dates.
ERROR GENERAR INFORME / Publicado por HYPERLINK "https://www.lawebdelprogramador.com/foros/usuario.php?id=363351"NEDERÂ (1 intervenciÃ³n) el 17/12/2020 20:39:17Hola buenas tardes, Quisiera por favor una ayuda con la generaciÃ³n de informes en Project. Necesito generar un informe donde se evidencia el porcentaje de avance del proyecto, las tareas retrasadas junto con sus dÃ­as de retraso, los dÃ­as de atraso del proyecto en general y las tareas completadas. He intentado por todos los medios que me aparezcan las tareas retrasadas y los dÃ­as, pero nada. Agradezco su ayuda.
ERROR GENERAR INFORME / Publicado por~NEDERÂ~(1 intervenciÃ³n) el 17/12/2020 20:39:17Hola buenas tardes, / Quisiera por favor una ayuda con la generaciÃ³n de informes en Project. Necesito generar un informe donde se evidencia el porcentaje de avance del proyecto, las tareas retrasadas junto con sus dÃ-as de retraso, los dÃ-as de atraso del proyecto en general y las tareas completadas. / He intentado por todos los medios que me aparezcan las tareas retrasadas y los dÃ-as, pero nada. / Agradezco su ayuda.

## Calendars

- CALENDARIO CARIBE AVENTURA: Mon-Fri 07:00-12:00, 13:00-16:30; Sat 07:00-12:00; Sun off. Exceptions (off unless hours are given): 2020-12-08 (Festivo Inmaculada Concepción), 2020-12-25 (Festivo Navidad), 2021-01-01 (Festivo Año nuevo), 2021-01-11 (Festivo día de Reyes Magos), 2021-03-22 (Festivo día de San José), 2021-04-01 to 2021-04-02 (Festivo Semana Santa).

## Schedule

| ID | WBS | Task | Duration | Start | Finish | Predecessors | Complete | Remaining | Baseline start | Baseline finish | Baseline duration | Total slack | Free slack | Constraint |
| --- | --- | --- | --- | --- | --- | --- | --- | --- | --- | --- | --- | --- | --- | --- |
| 1 | 1 | **SUBESTACIONES** | 137.19d | 2020-10-15 A | 2021-04-03 |  | 7% | 128.06d | 2020-10-15 | 2021-02-17 | 101.44d | 0d |  |  |
| 2 | 1.1 | **SUBESTACIÓN ELÉCTRICA PRINCIPAL** | 85.56d | 2020-11-10 A | 2021-02-23 |  | 8% | 78.29d | 2020-10-15 | 2021-01-12 | 71d | 30d |  |  |
| 3 | 1.1.1 | **EXCAVACIONES** | 34.56d | 2020-11-10 A | 2020-12-22 |  | 39% | 20.95d | 2020-11-10 | 2020-12-17 | 30.81d | 81d |  |  |
| 4 | 1.1.1.1 | Apertura zanja MT de S/E 1 a S/E 2 | 6d | 2020-11-10 A | 2020-11-17 A |  | 100% |  | 2020-11-10 | 2020-11-17 | 6d |  |  | start no earlier than 2020-11-10 |
| 5 | 1.1.1.2 | Adecuación MT zanja de S/E 1 a S/E 2 | 1d | 2020-11-17 A | 2020-11-18 A | 4 | 100% |  | 2020-11-17 | 2020-11-18 | 1d |  |  | start no earlier than 2020-11-10 |
| 6 | 1.1.1.3 | Instalación MT de tubería de S/E 1 a S/E 2 | 1d | 2020-11-18 A | 2020-11-19 A | 5 | 100% |  | 2020-11-18 | 2020-11-19 | 1d |  |  | start no earlier than 2020-11-10 |
| 7 | 1.1.1.4 | Tape zanja MT de S/E 1 a S/E 2 | 1d | 2020-11-19 A | 2020-11-20 A | 6 | 100% |  | 2020-11-19 | 2020-11-20 | 1d |  |  | start no earlier than 2020-11-10 |
| 8 | 1.1.1.5 | Construcción de cajas de inspección | 2d | 2020-12-01 A | 2020-12-11 |  | 20% | 1.6d | 2020-12-01 | 2020-12-03 | 2d | 89.4d |  | start no earlier than 2020-12-01 |
| 9 | 1.1.1.6 | **Construcción civil** | 16.75d | 2020-12-01 A | 2020-12-22 |  | 16% | 14.01d | 2020-12-01 | 2020-12-17 | 13d | 73d | 10.31d |  |
| 10 | 1.1.1.6.1 | Excavacion Mecánica area de subestación 1 | 3d | 2020-12-01 A | 2020-12-04 A |  | 100% |  | 2020-12-01 | 2020-12-04 | 3d |  |  | start no earlier than 2020-12-01 |
| 11 | 1.1.1.6.2 | Relleno y compactación por capas en recebo S/E1 | 2d | 2020-12-04 A | 2020-12-11 | 10 | 30% | 1.4d | 2020-12-04 | 2020-12-07 | 2d | 74.6d | 0d |  |
| 12 | 1.1.1.6.3 | Excavación Manual Vigas de cimentación S/E1 | 2d | 2020-12-11 | 2020-12-14 | 11 |  |  | 2020-12-07 | 2020-12-10 | 2d | 74.6d | 0d | start no earlier than 2020-12-09 |
| 13 | 1.1.1.6.4 | Armado de vigas de cimentación, placa y base de columnas S/E1 | 4d | 2020-12-14 | 2020-12-18 | 12 |  |  | 2020-12-10 | 2020-12-15 | 4d | 74.6d | 0d |  |
| 14 | 1.1.1.6.5 | Fundida de Vigas de Cimentación S/E1 | 1d | 2020-12-18 | 2020-12-19 | 13 |  |  | 2020-12-15 | 2020-12-16 | 1d | 74.6d |  |  |
| 15 | 1.1.1.6.6 | Armado de Columnas S/E1 | 1d | 2020-12-10 | 2020-12-10 | 10 |  |  | 2020-12-04 | 2020-12-04 | 1d | 73d | 0d | start no earlier than 2020-12-09 |
| 16 | 1.1.1.6.7 | Fundida de Columnas S/E1 | 1d | 2020-12-10 | 2020-12-11 | 15 |  |  | 2020-12-05 | 2020-12-07 | 1d | 73d | 0d | start no earlier than 2020-12-09 |
| 17 | 1.1.1.6.8 | Armado de placa y vigas Aéreas S/E1 | 5d | 2020-12-11 | 2020-12-17 | 16 |  |  | 2020-12-07 | 2020-12-14 | 5d | 73d | 0d | start no earlier than 2020-12-09 |
| 18 | 1.1.1.6.9 | Fundida de Placas y vigas Aéreas S/E1 | 1d | 2020-12-18 | 2020-12-18 | 17 |  |  | 2020-12-14 | 2020-12-15 | 1d | 73d | 0d |  |
| 19 | 1.1.1.6.10 | Levante de muros e instalación de puertas | 2d | 2020-12-18 | 2020-12-22 | 18 |  |  | 2020-12-15 | 2020-12-17 | 2d | 73d |  |  |
| 20 | 1.1.2 | **EQUIPOS** | 61d | 2020-12-10 | 2021-02-23 |  |  |  | 2020-10-15 | 2020-12-29 | 61d | 30d |  |  |
| 21 | 1.1.2.1 | Compra de equipos | 1d | 2020-12-10 | 2020-12-10 |  |  |  | 2020-10-15 | 2020-10-16 | 1d | 30d | 0d | start no earlier than 2020-12-09 |
| 22 | 1.1.2.2 | Llegada de equipos | 55d | 2020-12-10 | 2021-02-17 | 21 |  |  | 2020-10-16 | 2020-12-22 | 55d | 30d | 0d | start no earlier than 2020-12-09 |
| 23 | 1.1.2.3 | Instalación | 3d | 2021-02-17 | 2021-02-22 | 22 |  |  | 2020-12-22 | 2020-12-24 | 3d | 30d | 0d |  |
| 24 | 1.1.2.4 | Conexionado | 2d | 2021-02-22 | 2021-02-23 | 23 |  |  | 2020-12-24 | 2020-12-29 | 2d | 30d |  |  |

| ID | WBS | Task | Duration | Start | Finish | Predecessors | Complete | Remaining | Baseline start | Baseline finish | Baseline duration | Total slack | Free slack | Constraint |
| --- | --- | --- | --- | --- | --- | --- | --- | --- | --- | --- | --- | --- | --- | --- |
| 25 | 1.1.3 | **INSTALACIONES INTERNAS** | 49d | 2020-12-10 | 2021-02-09 |  |  |  | 2020-10-15 | 2021-01-12 | 71d | 42d |  |  |
| 26 | 1.1.3.1 | **GABINETES Y TABLEROS** | 49d | 2020-12-10 | 2021-02-09 |  |  |  | 2020-10-15 | 2020-12-14 | 49d | 42d |  |  |
| 27 | 1.1.3.1.1 | Compra de equipos | 1d | 2020-12-10 | 2020-12-10 |  |  |  | 2020-10-15 | 2020-10-16 | 1d | 42d | 0d | start no earlier than 2020-12-09 |
| 28 | 1.1.3.1.2 | Llegada de equipos | 45d | 2020-12-10 | 2021-02-05 | 27 |  |  | 2020-10-16 | 2020-12-09 | 45d | 42d | 0d | start no earlier than 2020-12-09 |
| 29 | 1.1.3.1.3 | Instalación | 1d | 2021-02-05 | 2021-02-06 | 28 |  |  | 2020-12-09 | 2020-12-10 | 1d | 42d | 0d | start no earlier than 2020-12-09 |
| 30 | 1.1.3.1.4 | Conexionado | 2d | 2021-02-06 | 2021-02-09 | 29 |  |  | 2020-12-10 | 2020-12-14 | 2d | 42d |  |  |
| 31 | 1.1.3.2 | **ALIMENTADORES** | 2d | 2020-12-10 | 2020-12-11 |  |  |  | 2020-12-04 | 2020-12-07 | 2d | 89d |  |  |
| 32 | 1.1.3.2.1 | Cableado | 2d | 2020-12-10 | 2020-12-11 |  |  |  | 2020-12-04 | 2020-12-07 | 2d | 89d |  | start no earlier than 2020-12-09 |
| 33 | 1.1.3.3 | **ILUMINACIÓN** | 4d | 2021-01-06 | 2021-01-12 |  |  |  | 2021-01-06 | 2021-01-12 | 4d | 66.19d |  |  |
| 34 | 1.1.3.3.1 | Instalación de tubería | 2d | 2021-01-06 | 2021-01-08 |  |  |  | 2021-01-06 | 2021-01-08 | 2d | 66.19d | 0d | start no earlier than 2021-01-06 |
| 35 | 1.1.3.3.2 | Cableado | 1d | 2021-01-08 | 2021-01-09 | 34 |  |  | 2021-01-08 | 2021-01-09 | 1d | 66.19d | 0d |  |
| 36 | 1.1.3.3.3 | Instalación de luminarias | 1d | 2021-01-09 | 2021-01-12 | 35 |  |  | 2021-01-09 | 2021-01-12 | 1d | 66.19d |  |  |
| 37 | 1.1.3.4 | **TOMACORRIENTES** | 4d | 2021-01-06 | 2021-01-12 |  |  |  | 2021-01-06 | 2021-01-12 | 4d | 66.19d |  |  |
| 38 | 1.1.3.4.1 | Instalación de tubería | 2d | 2021-01-06 | 2021-01-08 |  |  |  | 2021-01-06 | 2021-01-08 | 2d | 66.19d | 0d | start no earlier than 2021-01-06 |
| 39 | 1.1.3.4.2 | Cableado | 1d | 2021-01-08 | 2021-01-09 | 38 |  |  | 2021-01-08 | 2021-01-09 | 1d | 66.19d | 0d |  |
| 40 | 1.1.3.4.3 | Instalación de aparatos | 1d | 2021-01-09 | 2021-01-12 | 39 |  |  | 2021-01-09 | 2021-01-12 | 1d | 66.19d |  |  |
| 41 | 1.2 | **SUBESTACIÓN ELÉCTRICA 2-RIO LENTO** | 118.59d | 2020-10-15 A | 2021-03-09 |  | 8% | 109.4d | 2020-10-15 | 2021-02-17 | 101.44d | 18.6d |  |  |
| 42 | 1.2.1 | **EXCAVACIONES** | 57.5d | 2020-10-26 A | 2021-01-05 |  | 36% | 36.68d | 2020-10-15 | 2020-12-26 | 59.44d | 71d |  |  |
| 43 | 1.2.1.1 | Apertura zanja BT | 3d | 2020-10-26 A | 2020-10-29 A |  | 100% |  | 2020-10-26 | 2020-10-29 | 3d |  |  | start no earlier than 2020-10-26 |
| 44 | 1.2.1.2 | Adecuación zanja BT | 2d | 2020-10-29 A | 2020-12-10 | 43 | 95% | 0.1d | 2020-10-29 | 2020-10-30 | 2d | 0d |  |  |
| 45 | 1.2.1.3 | Instalación de tubería BT | 2d | 2020-10-30 A | 2020-12-10 | 44 | 95% | 0.1d | 2020-10-30 | 2020-11-03 | 2d | 0d |  |  |
| 46 | 1.2.1.4 | Tape zanja BT | 1d | 2020-11-03 A | 2020-12-10 | 45 | 95% | 0.05d | 2020-11-03 | 2020-11-04 | 1d | 0d |  |  |
| 47 | 1.2.1.5 | Apertura zanja de alumbrado exterior | 5d | 2020-11-04 A | 2020-12-10 | 46 | 95% | 0.25d | 2020-11-04 | 2020-11-10 | 5d | 0d |  |  |
| 48 | 1.2.1.6 | Adecuación zanja de alumbrado exterior | 5d | 2020-11-10 A | 2020-12-10 | 47 | 95% | 0.25d | 2020-11-10 | 2020-11-16 | 5d | 0d |  |  |
| 49 | 1.2.1.7 | Instalación de tubería de alumbrado exterior | 5d | 2020-11-16 A | 2020-12-10 | 48 | 95% | 0.25d | 2020-11-16 | 2020-11-21 | 5d | 0d |  |  |
| 50 | 1.2.1.8 | Tape zanja de iluminación de alumbrado exterior | 2d | 2020-11-21 A | 2020-12-11 | 49 | 95% | 0.1d | 2020-11-21 | 2020-11-24 | 2d | 67.9d | 50.27d |  |
| 51 | 1.2.1.9 | Construcción de cajas de inspección | 10d | 2020-12-10 | 2020-12-22 |  |  |  | 2020-10-15 | 2020-10-27 | 10d | 81d |  | start no earlier than 2020-12-09 |

| ID | WBS | Task | Duration | Start | Finish | Predecessors | Complete | Remaining | Baseline start | Baseline finish | Baseline duration | Total slack | Free slack | Constraint |
| --- | --- | --- | --- | --- | --- | --- | --- | --- | --- | --- | --- | --- | --- | --- |
| 52 | 1.2.1.10 | **Construcción civil** | 20d | 2020-12-10 | 2021-01-05 |  |  |  | 2020-12-01 | 2020-12-26 | 20d | 71d |  |  |
| 53 | 1.2.1.10.1 | Excavacion Mecánica area de subestación 2 | 3d | 2020-12-10 | 2020-12-14 |  |  |  | 2020-12-01 | 2020-12-04 | 3d | 71d | 0d | start no earlier than 2020-12-09 |
| 54 | 1.2.1.10.2 | Relleno y compactación por capas en recebo S/E2 | 2d | 2020-12-14 | 2020-12-16 | 53 |  |  | 2020-12-04 | 2020-12-07 | 2d | 77d | 0d | start no earlier than 2020-12-09 |
| 55 | 1.2.1.10.3 | Excavación Manual Vigas de cimentación S/E2 | 2d | 2020-12-16 | 2020-12-17 | 54 |  |  | 2020-12-07 | 2020-12-10 | 2d | 77d | 0d | start no earlier than 2020-12-09 |
| 56 | 1.2.1.10.4 | Armado de vigas de cimentación, placa y base de columnas S/E2 | 4d | 2020-12-18 | 2020-12-23 | 55 |  |  | 2020-12-10 | 2020-12-15 | 4d | 77d | 0d |  |
| 57 | 1.2.1.10.5 | Fundida de Vigas de Cimentación S/E2 | 3d | 2020-12-23 | 2020-12-28 | 56 |  |  | 2020-12-15 | 2020-12-18 | 3d | 77d |  |  |
| 58 | 1.2.1.10.6 | Armado de Columnas S/E2 | 3d | 2020-12-14 | 2020-12-17 | 53 |  |  | 2020-12-04 | 2020-12-09 | 3d | 71d | 0d | start no earlier than 2020-12-09 |
| 59 | 1.2.1.10.7 | Fundida de Columnas S/E2 | 2d | 2020-12-17 | 2020-12-18 | 58 |  |  | 2020-12-09 | 2020-12-11 | 2d | 71d | 0d | start no earlier than 2020-12-09 |
| 60 | 1.2.1.10.8 | Armado de placa y vigas Aéreas S/E2 | 6d | 2020-12-18 | 2020-12-28 | 59 |  |  | 2020-12-11 | 2020-12-18 | 6d | 71d | 0d |  |
| 61 | 1.2.1.10.9 | Fundida de Placas y vigas Aéreas S/E2 | 3d | 2020-12-28 | 2020-12-31 | 60 |  |  | 2020-12-18 | 2020-12-22 | 3d | 71d | 0d |  |
| 62 | 1.2.1.10.10 | Levante de muros e instalación de puertas | 3d | 2020-12-31 | 2021-01-05 | 61 |  |  | 2020-12-22 | 2020-12-26 | 3d | 71d |  |  |
| 63 | 1.2.2 | **EQUIPOS** | 61d | 2020-12-10 | 2021-02-23 |  |  |  | 2020-10-15 | 2020-12-29 | 61d | 30d |  |  |
| 64 | 1.2.2.1 | Compra de equipos | 1d | 2020-12-10 | 2020-12-10 |  |  |  | 2020-10-15 | 2020-10-16 | 1d | 30d | 0d | start no earlier than 2020-12-09 |
| 65 | 1.2.2.2 | Llegada de equipos | 55d | 2020-12-10 | 2021-02-17 | 64 |  |  | 2020-10-16 | 2020-12-22 | 55d | 30d | 0d | start no earlier than 2020-12-09 |
| 66 | 1.2.2.3 | Instalación | 3d | 2021-02-17 | 2021-02-22 | 65 |  |  | 2020-12-22 | 2020-12-24 | 3d | 30d | 0d |  |
| 67 | 1.2.2.4 | Conexionado | 2d | 2021-02-22 | 2021-02-23 | 66 |  |  | 2020-12-24 | 2020-12-29 | 2d | 30d |  |  |
| 68 | 1.2.3 | **INSTALACIONES INTERNAS** | 118.59d | 2020-10-15 A | 2021-03-09 |  | 2% | 116.32d | 2020-10-15 | 2021-02-17 | 101.44d | 18.6d |  |  |
| 69 | 1.2.3.1 | **GABINETES Y TABLEROS** | 69d | 2020-12-10 | 2021-03-04 |  |  |  | 2020-10-15 | 2021-01-08 | 69d | 22d |  |  |
| 70 | 1.2.3.1.1 | Compra de equipos | 1d | 2020-12-10 | 2020-12-10 |  |  |  | 2020-10-15 | 2020-10-16 | 1d | 22d | 0d | start no earlier than 2020-12-09 |
| 71 | 1.2.3.1.2 | Llegada de equipos | 45d | 2020-12-10 | 2021-02-05 | 70 |  |  | 2020-10-16 | 2020-12-09 | 45d | 22d | 0d | start no earlier than 2020-12-09 |
| 72 | 1.2.3.1.3 | Instalación | 1d | 2021-03-02 | 2021-03-02 | 71FS+20d |  |  | 2021-01-05 | 2021-01-06 | 1d | 22d | 0d |  |
| 73 | 1.2.3.1.4 | Conexionado | 2d | 2021-03-03 | 2021-03-04 | 72 |  |  | 2021-01-06 | 2021-01-08 | 2d | 22d |  |  |
| 74 | 1.2.3.2 | **TOBOGANES Y KOGUI** | 118.59d | 2020-10-15 A | 2021-03-09 |  | 7% | 110.2d | 2020-10-15 | 2021-01-16 | 75d | 18.6d |  |  |
| 75 | 1.2.3.2.1 | **ALIMENTADORES** | 23d | 2020-12-16 | 2021-01-15 |  |  |  | 2020-12-16 | 2021-01-15 | 23d | 62.88d |  |  |
| 76 | 1.2.3.2.1.1 | Cableado | 23d | 2020-12-16 | 2021-01-15 |  |  |  | 2020-12-16 | 2021-01-15 | 23d | 62.88d |  | start no earlier than 2020-12-16 |

| ID | WBS | Task | Duration | Start | Finish | Predecessors | Complete | Remaining | Baseline start | Baseline finish | Baseline duration | Total slack | Free slack | Constraint |
| --- | --- | --- | --- | --- | --- | --- | --- | --- | --- | --- | --- | --- | --- | --- |
| 77 | 1.2.3.2.2 | **ILUMINACIÓN** | 66.19d | 2020-10-15 A | 2021-01-05 |  | 9% | 60.17d | 2020-10-15 | 2020-11-10 | 22d | 71d |  |  |
| 78 | 1.2.3.2.2.1 | Instalación de tubería | 10d | 2020-10-15 A | 2020-12-18 |  | 20% | 8d | 2020-10-15 | 2020-10-27 | 10d | 71d | 0d |  |
| 79 | 1.2.3.2.2.2 | Cableado | 4d | 2020-12-18 | 2020-12-24 | 78 |  |  | 2020-10-27 | 2020-10-31 | 4d | 71d | 0d | start no earlier than 2020-12-09 |
| 80 | 1.2.3.2.2.3 | Instalación de luminarias | 8d | 2020-12-24 | 2021-01-05 | 79 |  |  | 2020-10-31 | 2020-11-10 | 8d | 71d |  | start no earlier than 2020-12-09 |
| 81 | 1.2.3.2.3 | **TOMACORRIENTES** | 118.59d | 2020-10-15 A | 2021-03-09 |  | 13% | 103.17d | 2020-10-15 | 2021-01-16 | 75d | 18.6d |  |  |
| 82 | 1.2.3.2.3.1 | Instalación de tubería | 13d | 2020-10-15 A | 2020-12-22 |  | 20% | 10.4d | 2020-10-15 | 2020-10-30 | 13d | 18.6d | 0d |  |
| 83 | 1.2.3.2.3.2 | Cableado | 4d | 2021-03-01 | 2021-03-05 | 82FS+55d |  |  | 2021-01-07 | 2021-01-13 | 4d | 18.6d | 0d |  |
| 84 | 1.2.3.2.3.3 | Instalación de aparatos | 3d | 2021-03-05 | 2021-03-09 | 83 |  |  | 2021-01-13 | 2021-01-16 | 3d | 18.6d |  |  |
| 85 | 1.2.3.3 | **FOOD COURT GRAN SINÚ** | 33d | 2020-12-10 | 2021-01-21 |  |  |  | 2020-12-01 | 2021-01-15 | 34.88d | 58d |  |  |
| 86 | 1.2.3.3.1 | **ALIMENTADORES** | 23d | 2020-12-16 | 2021-01-15 |  |  |  | 2020-12-16 | 2021-01-15 | 23d | 62.88d |  |  |
| 87 | 1.2.3.3.1.1 | Cableado | 23d | 2020-12-16 | 2021-01-15 |  |  |  | 2020-12-16 | 2021-01-15 | 23d | 62.88d |  | start no earlier than 2020-12-16 |
| 88 | 1.2.3.3.2 | **ILUMINACIÓN** | 12d | 2020-12-10 | 2020-12-24 |  |  |  | 2020-12-01 | 2020-12-16 | 12d | 79d |  |  |
| 89 | 1.2.3.3.2.1 | Instalación de tubería | 5d | 2020-12-10 | 2020-12-16 |  |  |  | 2020-12-01 | 2020-12-07 | 5d | 79d | 0d | start no earlier than 2020-12-09 |
| 90 | 1.2.3.3.2.2 | Cableado | 2d | 2020-12-16 | 2020-12-17 | 89 |  |  | 2020-12-07 | 2020-12-10 | 2d | 79d | 0d | start no earlier than 2020-12-09 |
| 91 | 1.2.3.3.2.3 | Instalación de luminarias | 5d | 2020-12-18 | 2020-12-24 | 90 |  |  | 2020-12-10 | 2020-12-16 | 5d | 79d |  |  |
| 92 | 1.2.3.3.3 | **TOMACORRIENTES** | 33d | 2020-12-10 | 2021-01-21 |  |  |  | 2020-12-01 | 2021-01-13 | 33d | 58d |  |  |
| 93 | 1.2.3.3.3.1 | Instalación de tubería | 5d | 2020-12-10 | 2020-12-16 |  |  |  | 2020-12-01 | 2020-12-07 | 5d | 58d | 0d | start no earlier than 2020-12-09 |
| 94 | 1.2.3.3.3.2 | Cableado | 2d | 2021-01-18 | 2021-01-20 | 93FS+25d |  |  | 2021-01-08 | 2021-01-12 | 2d | 58d | 0d |  |
| 95 | 1.2.3.3.3.3 | Instalación de aparatos | 1d | 2021-01-20 | 2021-01-21 | 94 |  |  | 2021-01-12 | 2021-01-13 | 1d | 58d |  |  |
| 96 | 1.2.3.4 | **PLAZOLETA** | 62d | 2020-12-10 | 2021-02-24 |  |  |  | 2020-12-01 | 2021-02-17 | 62d | 29d |  |  |
| 97 | 1.2.3.4.1 | **ALIMENTADORES** | 23d | 2020-12-16 | 2021-01-15 |  |  |  | 2020-12-16 | 2021-01-15 | 23d | 62.88d |  |  |
| 98 | 1.2.3.4.1.1 | Cableado | 23d | 2020-12-16 | 2021-01-15 |  |  |  | 2020-12-16 | 2021-01-15 | 23d | 62.88d |  | start no earlier than 2020-12-16 |
| 99 | 1.2.3.4.2 | **ILUMINACIÓN** | 62d | 2020-12-10 | 2021-02-24 |  |  |  | 2020-12-01 | 2021-02-17 | 62d | 29d |  |  |
| 100 | 1.2.3.4.2.1 | Instalación de tubería | 5d | 2020-12-10 | 2020-12-16 |  |  |  | 2020-12-01 | 2020-12-07 | 5d | 29d | 0d | start no earlier than 2020-12-09 |
| 101 | 1.2.3.4.2.2 | Cableado | 2d | 2020-12-16 | 2020-12-17 | 100 |  |  | 2020-12-07 | 2020-12-10 | 2d | 29d | 0d | start no earlier than 2020-12-09 |
| 102 | 1.2.3.4.2.3 | Instalación de luminarias | 5d | 2021-02-18 | 2021-02-24 | 101FS+50d |  |  | 2021-02-11 | 2021-02-17 | 5d | 29d |  |  |

Notes:
- 89: No hay construcción de locales y plazoleta
- 93: No hay construcción de obra civil para realizar las instalaciones eléctricas

| ID | WBS | Task | Duration | Start | Finish | Predecessors | Complete | Remaining | Baseline start | Baseline finish | Baseline duration | Total slack | Free slack | Constraint |
| --- | --- | --- | --- | --- | --- | --- | --- | --- | --- | --- | --- | --- | --- | --- |
| 103 | 1.2.3.4.3 | **TOMACORRIENTES** | 8d | 2020-12-10 | 2020-12-18 |  |  |  | 2020-12-01 | 2020-12-11 | 8d | 83d |  |  |
| 104 | 1.2.3.4.3.1 | Instalación de tubería | 5d | 2020-12-10 | 2020-12-16 |  |  |  | 2020-12-01 | 2020-12-07 | 5d | 83d | 0d | start no earlier than 2020-12-09 |
| 105 | 1.2.3.4.3.2 | Cableado | 2d | 2020-12-16 | 2020-12-17 | 104 |  |  | 2020-12-07 | 2020-12-10 | 2d | 83d | 0d | start no earlier than 2020-12-09 |
| 106 | 1.2.3.4.3.3 | Instalación de aparatos | 1d | 2020-12-18 | 2020-12-18 | 105 |  |  | 2020-12-10 | 2020-12-11 | 1d | 83d |  |  |
| 107 | 1.2.3.5 | **TAQUILLA** | 51.81d | 2020-12-10 | 2021-02-12 |  |  |  | 2020-12-09 | 2021-02-12 | 52.62d | 39.19d |  |  |
| 108 | 1.2.3.5.1 | **ALIMENTADORES** | 23d | 2020-12-16 | 2021-01-15 |  |  |  | 2020-12-16 | 2021-01-15 | 23d | 62.88d |  |  |
| 109 | 1.2.3.5.1.1 | Cableado | 23d | 2020-12-16 | 2021-01-15 |  |  |  | 2020-12-16 | 2021-01-15 | 23d | 62.88d |  | start no earlier than 2020-12-16 |
| 110 | 1.2.3.5.2 | **ILUMINACIÓN** | 31d | 2021-01-06 | 2021-02-12 |  |  |  | 2021-01-06 | 2021-02-12 | 31d | 39.19d |  |  |
| 111 | 1.2.3.5.2.1 | Instalación de tubería | 4d | 2021-01-06 | 2021-01-12 |  |  |  | 2021-01-06 | 2021-01-12 | 4d | 39.19d | 0d | start no earlier than 2021-01-06 |
| 112 | 1.2.3.5.2.2 | Cableado | 2d | 2021-01-12 | 2021-01-14 | 111 |  |  | 2021-01-12 | 2021-01-14 | 2d | 39.19d | 0d |  |
| 113 | 1.2.3.5.2.3 | Instalación de luminarias | 5d | 2021-02-06 | 2021-02-12 | 112FS+20d |  |  | 2021-02-06 | 2021-02-12 | 5d | 39.19d |  |  |
| 114 | 1.2.3.5.3 | **TOMACORRIENTES** | 25d | 2020-12-10 | 2021-01-12 |  |  |  | 2020-12-09 | 2021-01-09 | 25d | 66d |  |  |
| 115 | 1.2.3.5.3.1 | Instalación de tubería | 4d | 2020-12-10 | 2020-12-15 |  |  |  | 2020-12-09 | 2020-12-14 | 4d | 66d | 0d | start no earlier than 2020-12-09 |
| 116 | 1.2.3.5.3.2 | Cableado | 2d | 2021-01-07 | 2021-01-09 | 115FS+18d |  |  | 2021-01-06 | 2021-01-08 | 2d | 66d | 0d |  |
| 117 | 1.2.3.5.3.3 | Instalación de aparatos | 1d | 2021-01-09 | 2021-01-12 | 116 |  |  | 2021-01-08 | 2021-01-09 | 1d | 66d |  |  |
| 118 | 1.3 | **SUBESTACIÓN ELÉCTRICA 3-TAYRONA** | 107.19d | 2020-10-15 A | 2021-02-23 |  | 9% | 97.01d | 2020-10-15 | 2020-12-29 | 61d | 30d |  |  |
| 119 | 1.3.1 | **EXCAVACIONES** | 60.5d | 2020-10-15 A | 2020-12-28 |  | 22% | 47.31d | 2020-10-15 | 2020-12-28 | 60.5d | 76.69d |  |  |
| 120 | 1.3.1.1 | Apertura zanja MT de S/E 3 a S/E 4 | 3d | 2020-12-01 A | 2020-12-04 A |  | 100% |  | 2020-12-01 | 2020-12-04 | 3d |  |  | start no earlier than 2020-11-10 |
| 121 | 1.3.1.2 | Adecuación zanja MT de S/E 3 a S/E 4 | 2d | 2020-11-17 A | 2020-12-04 A | 120 | 100% |  | 2020-11-17 | 2020-12-04 | 2d |  |  | start no earlier than 2020-11-10 |
| 122 | 1.3.1.3 | Instalación de tubería MT de S/E 3 a S/E 4 | 2d | 2020-11-18 A | 2020-12-07 A | 121 | 100% |  | 2020-11-18 | 2020-12-07 | 2d |  |  | start no earlier than 2020-11-10 |
| 123 | 1.3.1.4 | Tape zanja MT de S/E 3 a S/E 4 | 1d | 2020-11-19 A | 2020-11-20 A | 122 | 100% |  | 2020-11-19 | 2020-11-20 | 1d |  |  | start no earlier than 2020-11-10 |
| 124 | 1.3.1.5 | Apertura zanja BT | 4d | 2020-10-15 A | 2020-12-14 |  | 15% | 3.4d | 2020-10-15 | 2020-10-20 | 4d | 0d |  |  |
| 125 | 1.3.1.6 | Adecuación zanja BT | 3d | 2020-10-15 A | 2020-12-17 | 124 | 15% | 2.55d | 2020-10-15 | 2020-10-22 | 3d | 0d |  |  |
| 126 | 1.3.1.7 | Instalación de tubería BT | 1d | 2020-10-15 A | 2020-12-17 | 125 | 15% | 0.85d | 2020-10-15 | 2020-10-23 | 1d | 0d |  |  |
| 127 | 1.3.1.8 | Tape zanja BT | 1d | 2020-10-15 A | 2020-12-18 | 126 | 15% | 0.85d | 2020-10-15 | 2020-10-24 | 1d | 83.35d |  |  |
| 128 | 1.3.1.9 | Apertura zanja para alumbrado exterior | 2d | 2020-10-15 A | 2020-12-11 |  | 15% | 1.7d | 2020-10-15 | 2020-10-17 | 2d | 0d |  |  |
| 129 | 1.3.1.10 | Adecuación zanja para alumbrado exterior | 2d | 2020-10-15 A | 2020-12-14 | 128 | 15% | 1.7d | 2020-10-15 | 2020-10-20 | 2d | 0d |  |  |
| 130 | 1.3.1.11 | Instalación de tubería para alumbrado exterior | 1d | 2020-10-15 A | 2020-12-15 | 129 | 15% | 0.85d | 2020-10-15 | 2020-10-20 | 1d | 0d |  |  |
| 131 | 1.3.1.12 | Tape zanja para alumbrado exterior | 1d | 2020-10-15 A | 2020-12-16 | 130 | 15% | 0.85d | 2020-10-15 | 2020-10-21 | 1d | 63.9d | 46.27d |  |
| 132 | 1.3.1.13 | Construcción de cajas de inspección | 2d | 2020-12-10 | 2020-12-11 |  |  |  | 2020-12-01 | 2020-12-03 | 2d | 81d | 18.31d | start no earlier than 2020-12-09 |

Notes:
- 104: No hay construcción de obra civil para realizar las instalaciones eléctricas
- 124: No se ha hecho marcación por parte de topografía para excavación.

| ID | WBS | Task | Duration | Start | Finish | Predecessors | Complete | Remaining | Baseline start | Baseline finish | Baseline duration | Total slack | Free slack | Constraint |
| --- | --- | --- | --- | --- | --- | --- | --- | --- | --- | --- | --- | --- | --- | --- |
| 133 | 1.3.1.14 | **Construcción civil** | 13d | 2020-12-11 | 2020-12-28 |  |  |  | 2020-12-11 | 2020-12-28 | 13d | 68.69d | 6d |  |
| 134 | 1.3.1.14.1 | Excavacion Mecánica area de subestación 1 | 3d | 2020-12-11 | 2020-12-15 |  |  |  | 2020-12-11 | 2020-12-15 | 3d | 68.69d | 0d | start no earlier than 2020-12-11 |
| 135 | 1.3.1.14.2 | Relleno y compactación por capas en recebo S/E1 | 2d | 2020-12-15 | 2020-12-17 | 134 |  |  | 2020-12-15 | 2020-12-17 | 2d | 69.69d | 0d |  |
| 136 | 1.3.1.14.3 | Excavación Manual Vigas de cimentación S/E1 | 2d | 2020-12-17 | 2020-12-19 | 135 |  |  | 2020-12-17 | 2020-12-19 | 2d | 69.69d | 0d |  |
| 137 | 1.3.1.14.4 | Armado de vigas de cimentación, placa y base de columnas S/E1 | 4d | 2020-12-19 | 2020-12-24 | 136 |  |  | 2020-12-19 | 2020-12-24 | 4d | 69.69d | 0d |  |
| 138 | 1.3.1.14.5 | Fundida de Vigas de Cimentación S/E1 | 1d | 2020-12-24 | 2020-12-26 | 137 |  |  | 2020-12-24 | 2020-12-26 | 1d | 69.69d |  |  |
| 139 | 1.3.1.14.6 | Armado de Columnas S/E1 | 1d | 2020-12-15 | 2020-12-16 | 134 |  |  | 2020-12-15 | 2020-12-16 | 1d | 68.69d | 0d |  |
| 140 | 1.3.1.14.7 | Fundida de Columnas S/E1 | 1d | 2020-12-16 | 2020-12-17 | 139 |  |  | 2020-12-16 | 2020-12-17 | 1d | 68.69d | 0d |  |
| 141 | 1.3.1.14.8 | Armado de placa y vigas Aéreas S/E1 | 5d | 2020-12-17 | 2020-12-23 | 140 |  |  | 2020-12-17 | 2020-12-23 | 5d | 68.69d | 0d |  |
| 142 | 1.3.1.14.9 | Fundida de Placas y vigas Aéreas S/E1 | 1d | 2020-12-23 | 2020-12-24 | 141 |  |  | 2020-12-23 | 2020-12-24 | 1d | 68.69d | 0d |  |
| 143 | 1.3.1.14.10 | Levante de muros e instalación de puertas | 2d | 2020-12-24 | 2020-12-28 | 142 |  |  | 2020-12-24 | 2020-12-28 | 2d | 68.69d |  |  |
| 144 | 1.3.2 | **EQUIPOS** | 61d | 2020-12-10 | 2021-02-23 |  |  |  | 2020-10-15 | 2020-12-29 | 61d | 30d |  |  |
| 145 | 1.3.2.1 | Compra de equipos | 1d | 2020-12-10 | 2020-12-10 |  |  |  | 2020-10-15 | 2020-10-16 | 1d | 30d | 0d | start no earlier than 2020-12-09 |
| 146 | 1.3.2.2 | Llegada de equipos | 55d | 2020-12-10 | 2021-02-17 | 145 |  |  | 2020-10-16 | 2020-12-22 | 55d | 30d | 0d | start no earlier than 2020-12-09 |
| 147 | 1.3.2.3 | Instalación | 3d | 2021-02-17 | 2021-02-22 | 146 |  |  | 2020-12-22 | 2020-12-24 | 3d | 30d | 0d |  |
| 148 | 1.3.2.4 | Conexionado | 2d | 2021-02-22 | 2021-02-23 | 147 |  |  | 2020-12-24 | 2020-12-29 | 2d | 30d |  |  |
| 149 | 1.4 | **SUBESTACIÓN ELÉCTRICA 4-TORBELLINO-COCO SPLASH** | 87.75d | 2020-12-01 A | 2021-03-18 |  | 6% | 82.8d | 2020-10-15 | 2021-01-23 | 81d | 10d |  |  |
| 150 | 1.4.1 | **EXCAVACIONES** | 27.06d | 2020-12-01 A | 2021-01-05 |  | 21% | 21.27d | 2020-10-15 | 2021-01-05 | 66.5d | 70.69d |  |  |
| 151 | 1.4.1.1 | Apertura zanja MT de S/E 4 a S/E 5 | 5d | 2020-12-01 A | 2020-12-10 |  | 80% | 1d | 2020-12-01 | 2020-12-07 | 5d | 0d |  | start no earlier than 2020-12-01 |
| 152 | 1.4.1.2 | Adecuación zanja MT de S/E 4 a S/E 5 | 1d | 2020-12-07 A | 2020-12-11 | 151 | 80% | 0.2d | 2020-12-07 | 2020-12-09 | 1d | 0d |  |  |
| 153 | 1.4.1.3 | Instalación de tubería MT de S/E 4 a S/E 5 | 2d | 2020-12-09 A | 2020-12-11 | 152 | 80% | 0.4d | 2020-12-09 | 2020-12-11 | 2d | 0.45d | 0d |  |
| 154 | 1.4.1.4 | Tape zanja MT de S/E 4 a S/E 5 | 1d | 2020-12-11 A | 2020-12-12 | 153 | 80% | 0.2d | 2020-12-11 | 2020-12-12 | 1d | 88.75d |  |  |
| 155 | 1.4.1.5 | Apertura zanja BT | 1d | 2020-12-01 A | 2020-12-10 |  | 40% | 0.6d | 2020-12-01 | 2020-12-02 | 1d | 0d |  | start no earlier than 2020-12-01 |
| 156 | 1.4.1.6 | Adecuación zanja BT | 1d | 2020-12-02 A | 2020-12-11 | 155 | 40% | 0.6d | 2020-12-02 | 2020-12-03 | 1d | 0d |  |  |
| 157 | 1.4.1.7 | Instalación de tubería BT | 2d | 2020-12-03 A | 2020-12-12 | 156 | 40% | 1.2d | 2020-12-03 | 2020-12-04 | 2d | 0d |  |  |
| 158 | 1.4.1.8 | Tape zanja BT | 1d | 2020-12-05 A | 2020-12-14 | 157 | 40% | 0.6d | 2020-12-05 | 2020-12-07 | 1d | 88d |  |  |
| 159 | 1.4.1.9 | Apertura zanja de alumbrado exterior | 1d | 2020-12-10 | 2020-12-10 |  |  |  | 2020-12-01 | 2020-12-02 | 1d | 63d | 0d | start no earlier than 2020-12-09 |
| 160 | 1.4.1.10 | Adecuación zanja de alumbrado exterior | 3d | 2020-12-10 | 2020-12-15 | 159 |  |  | 2020-12-02 | 2020-12-04 | 3d | 63d | 0d | start no earlier than 2020-12-09 |
| 161 | 1.4.1.11 | Instalación de tubería de alumbrado exterior | 1d | 2020-12-15 | 2020-12-16 | 160 |  |  | 2020-12-05 | 2020-12-07 | 1d | 63d | 0d | start no earlier than 2020-12-09 |
| 162 | 1.4.1.12 | Tape zanja de alumbrado exterior | 1d | 2020-12-16 | 2020-12-17 | 161 |  |  | 2020-12-07 | 2020-12-09 | 1d | 63d | 45.38d | start no earlier than 2020-12-09 |
| 163 | 1.4.1.13 | Construcción de cajas de inspección | 5d | 2020-12-10 | 2020-12-16 |  |  |  | 2020-10-15 | 2020-10-21 | 5d | 86d |  | start no earlier than 2020-12-09 |

| ID | WBS | Task | Duration | Start | Finish | Predecessors | Baseline start | Baseline finish | Baseline duration | Total slack | Free slack | Constraint |
| --- | --- | --- | --- | --- | --- | --- | --- | --- | --- | --- | --- | --- |
| 164 | 1.4.1.14 | **Construcción civil** | 12d | 2020-12-19 | 2021-01-05 |  | 2020-12-19 | 2021-01-05 | 12d | 62.69d | 0d |  |
| 165 | 1.4.1.14.1 | Excavación Mecanica área de subestación 4 | 3d | 2020-12-19 | 2020-12-23 |  | 2020-12-19 | 2020-12-23 | 3d | 62.69d | 0d | start no earlier than 2020-12-19 |
| 166 | 1.4.1.14.2 | Relleno y compactación por capas en recebo S/E 4 | 2d | 2020-12-23 | 2020-12-26 | 165 | 2020-12-23 | 2020-12-26 | 2d | 65.69d | 0d |  |
| 167 | 1.4.1.14.3 | Excavación Manual Vigas de cimentación S/E 4 | 1d | 2020-12-26 | 2020-12-28 | 166 | 2020-12-26 | 2020-12-28 | 1d | 65.69d | 0d |  |
| 168 | 1.4.1.14.4 | Armado de vigas de cimentación, placa y base de columnas S/E 4 | 2d | 2020-12-28 | 2020-12-30 | 167 | 2020-12-28 | 2020-12-30 | 2d | 65.69d | 0d |  |
| 169 | 1.4.1.14.5 | Fundida de Vigas de Cimentación S/E 4 | 1d | 2020-12-30 | 2020-12-31 | 168 | 2020-12-30 | 2020-12-31 | 1d | 65.69d |  |  |
| 170 | 1.4.1.14.6 | Armado de Columnas S/E 4 | 2d | 2020-12-23 | 2020-12-26 | 165 | 2020-12-23 | 2020-12-26 | 2d | 62.69d | 0d |  |
| 171 | 1.4.1.14.7 | Fundida de Columnas S/E 4 | 1d | 2020-12-26 | 2020-12-28 | 170 | 2020-12-26 | 2020-12-28 | 1d | 62.69d | 0d |  |
| 172 | 1.4.1.14.8 | Armado de placa y vigas Aéreas S/E 4 | 3d | 2020-12-28 | 2020-12-31 | 171 | 2020-12-28 | 2020-12-31 | 3d | 62.69d | 0d |  |
| 173 | 1.4.1.14.9 | Fundida de Placas y vigas Aéreas S/E 4 | 1d | 2020-12-31 | 2021-01-02 | 172 | 2020-12-31 | 2021-01-02 | 1d | 62.69d | 0d |  |
| 174 | 1.4.1.14.10 | Levante de muros e instalación de puertas | 2d | 2021-01-02 | 2021-01-05 | 173 | 2021-01-02 | 2021-01-05 | 2d | 62.69d |  |  |
| 175 | 1.4.2 | **EQUIPOS** | 81d | 2020-12-10 | 2021-03-18 |  | 2020-10-15 | 2021-01-23 | 81d | 10d |  |  |
| 176 | 1.4.2.1 | Compra de equipos | 1d | 2020-12-10 | 2020-12-10 |  | 2020-10-15 | 2020-10-16 | 1d | 10d | 0d | start no earlier than 2020-12-09 |
| 177 | 1.4.2.2 | Llegada de equipos | 55d | 2020-12-10 | 2021-02-17 | 176 | 2020-10-16 | 2020-12-22 | 55d | 10d | 0d | start no earlier than 2020-12-09 |
| 178 | 1.4.2.3 | Instalación | 3d | 2021-03-12 | 2021-03-17 | 177FS+20d | 2021-01-18 | 2021-01-21 | 3d | 10d | 0d |  |
| 179 | 1.4.2.4 | Conexionado | 2d | 2021-03-17 | 2021-03-18 | 178 | 2021-01-21 | 2021-01-23 | 2d | 10d |  |  |
| 180 | 1.4.3 | **INSTALACIONES INTERNAS** | 49d | 2020-12-10 | 2021-02-09 |  | 2020-10-15 | 2021-01-12 | 71d | 42d |  |  |
| 181 | 1.4.3.1 | **GABINETES Y TABLEROS** | 49d | 2020-12-10 | 2021-02-09 |  | 2020-10-15 | 2020-12-14 | 49d | 42d |  |  |
| 182 | 1.4.3.1.1 | Compra de equipos | 1d | 2020-12-10 | 2020-12-10 |  | 2020-10-15 | 2020-10-16 | 1d | 42d | 0d | start no earlier than 2020-12-09 |
| 183 | 1.4.3.1.2 | Llegada de equipos | 45d | 2020-12-10 | 2021-02-05 | 182 | 2020-10-16 | 2020-12-09 | 45d | 42d | 0d | start no earlier than 2020-12-09 |
| 184 | 1.4.3.1.3 | Instalación | 1d | 2021-02-05 | 2021-02-06 | 183 | 2020-12-09 | 2020-12-10 | 1d | 42d | 0d | start no earlier than 2020-12-09 |
| 185 | 1.4.3.1.4 | Conexionado | 2d | 2021-02-06 | 2021-02-09 | 184 | 2020-12-10 | 2020-12-14 | 2d | 42d |  |  |
| 186 | 1.4.3.2 | **ALIMENTADORES** | 2d | 2020-12-10 | 2020-12-11 |  | 2020-12-04 | 2020-12-07 | 2d | 89d |  |  |
| 187 | 1.4.3.2.1 | Cableado | 2d | 2020-12-10 | 2020-12-11 |  | 2020-12-04 | 2020-12-07 | 2d | 89d |  | start no earlier than 2020-12-09 |

Notes:
- 176: No se han comprado debido a que no existen diseños actualizados como consecuencia del aumento de cargas. Se mandarán a fabricar una vez entreguen los diseños.
- 187: Se está en espera del rediseño para proceder con el tendido de los alimentadores.

| ID | WBS | Task | Duration | Start | Finish | Predecessors | Baseline start | Baseline finish | Baseline duration | Total slack | Free slack | Constraint |
| --- | --- | --- | --- | --- | --- | --- | --- | --- | --- | --- | --- | --- |
| 188 | 1.4.3.3 | **ILUMINACIÓN** | 4d | 2021-01-06 | 2021-01-12 |  | 2021-01-06 | 2021-01-12 | 4d | 66.19d |  |  |
| 189 | 1.4.3.3.1 | Instalación de tubería | 2d | 2021-01-06 | 2021-01-08 |  | 2021-01-06 | 2021-01-08 | 2d | 66.19d | 0d | start no earlier than 2021-01-06 |
| 190 | 1.4.3.3.2 | Cableado | 1d | 2021-01-08 | 2021-01-09 | 189 | 2021-01-08 | 2021-01-09 | 1d | 66.19d | 0d |  |
| 191 | 1.4.3.3.3 | Instalación de luminarias | 1d | 2021-01-09 | 2021-01-12 | 190 | 2021-01-09 | 2021-01-12 | 1d | 66.19d |  |  |
| 192 | 1.4.3.4 | **TOMACORRIENTES** | 4d | 2021-01-06 | 2021-01-12 |  | 2021-01-06 | 2021-01-12 | 4d | 66.19d |  |  |
| 193 | 1.4.3.4.1 | Instalación de tubería | 2d | 2021-01-06 | 2021-01-08 |  | 2021-01-06 | 2021-01-08 | 2d | 66.19d | 0d | start no earlier than 2021-01-06 |
| 194 | 1.4.3.4.2 | Cableado | 1d | 2021-01-08 | 2021-01-09 | 193 | 2021-01-08 | 2021-01-09 | 1d | 66.19d | 0d |  |
| 195 | 1.4.3.4.3 | Instalación de aparatos | 1d | 2021-01-09 | 2021-01-12 | 194 | 2021-01-09 | 2021-01-12 | 1d | 66.19d |  |  |
| 196 | 1.5 | **SUBESTACIÓN ELÉCTRICA 5-ISLAS DEL ROSARIO** | 91d | 2020-12-10 | 2021-04-03 |  | 2020-10-15 | 2021-02-12 | 98.56d | 0d |  |  |
| 197 | 1.5.1 | **EXCAVACIONES** | 44.06d | 2020-12-19 | 2021-02-12 |  | 2020-12-19 | 2021-02-12 | 44.06d | 38.62d |  |  |
| 198 | 1.5.1.1 | Apertura zanja MT de S/E 4 a S/E 5 | 4d | 2021-02-01 | 2021-02-04 |  | 2021-02-01 | 2021-02-04 | 4d | 40.62d | 0d | start no earlier than 2021-02-01 |
| 199 | 1.5.1.2 | Adecuación zanja MT de S/E 4 a S/E 5 | 2d | 2021-02-05 | 2021-02-08 | 198 | 2021-02-05 | 2021-02-08 | 2d | 40.62d | 0d |  |
| 200 | 1.5.1.3 | Instalación de tubería MT de S/E 4 a S/E 5 | 2d | 2021-02-08 | 2021-02-10 | 199 | 2021-02-08 | 2021-02-10 | 2d | 40.62d | 0d |  |
| 201 | 1.5.1.4 | Tape zanja MT de S/E 4 a S/E 5 | 1d | 2021-02-10 | 2021-02-11 | 200 | 2021-02-10 | 2021-02-11 | 1d | 40.62d |  |  |
| 202 | 1.5.1.5 | Apertura zanja BT | 5d | 2021-02-01 | 2021-02-05 |  | 2021-02-01 | 2021-02-05 | 5d | 38.62d | 0d | start no earlier than 2021-02-01 |
| 203 | 1.5.1.6 | Adecuación zanja BT | 2d | 2021-02-05 | 2021-02-09 | 202 | 2021-02-05 | 2021-02-09 | 2d | 38.62d | 0d |  |
| 204 | 1.5.1.7 | Instalación de tubería BT | 3d | 2021-02-09 | 2021-02-12 | 203 | 2021-02-09 | 2021-02-12 | 3d | 38.62d | 0d |  |
| 205 | 1.5.1.8 | Tape zanja BT | 1d | 2021-02-12 | 2021-02-12 | 204 | 2021-02-12 | 2021-02-12 | 1d | 38.62d |  |  |
| 206 | 1.5.1.9 | Apertura zanja de alumbrado exterior | 5d | 2021-02-01 | 2021-02-05 |  | 2021-02-01 | 2021-02-05 | 5d | 17.62d | 0d | start no earlier than 2021-02-01 |
| 207 | 1.5.1.10 | Adecuación zanja de alumbrado exterior | 3d | 2021-02-05 | 2021-02-10 | 206 | 2021-02-05 | 2021-02-10 | 3d | 17.62d | 0d |  |
| 208 | 1.5.1.11 | Instalación de tubería de alumbrado exterior | 1d | 2021-02-10 | 2021-02-11 | 207 | 2021-02-10 | 2021-02-11 | 1d | 17.62d | 0d |  |
| 209 | 1.5.1.12 | Tape zanja de alumbrado exterior | 1d | 2021-02-11 | 2021-02-12 | 208 | 2021-02-11 | 2021-02-12 | 1d | 17.62d | 0d |  |
| 210 | 1.5.1.13 | Construcción de cajas de inspección | 15d | 2021-01-08 | 2021-01-27 |  | 2021-01-08 | 2021-01-27 | 15d | 53.06d |  | start no earlier than 2021-01-08 |
| 211 | 1.5.1.14 | **Construcción civil** | 12d | 2020-12-19 | 2021-01-05 |  | 2020-12-19 | 2021-01-05 | 12d | 62.69d | 0d |  |
| 212 | 1.5.1.14.1 | Excavación Mecanica área de subestación 5 | 3d | 2020-12-19 | 2020-12-23 |  | 2020-12-19 | 2020-12-23 | 3d | 62.69d | 0d | start no earlier than 2020-12-19 |
| 213 | 1.5.1.14.2 | Relleno y compactación por capas en recebo S/E 5 | 2d | 2020-12-23 | 2020-12-26 | 212 | 2020-12-23 | 2020-12-26 | 2d | 65.69d | 0d |  |
| 214 | 1.5.1.14.3 | Excavación Manual Vigas de cimentación S/E 5 | 1d | 2020-12-26 | 2020-12-28 | 213 | 2020-12-26 | 2020-12-28 | 1d | 65.69d | 0d |  |
| 215 | 1.5.1.14.4 | Armado de vigas de cimentación, placa y base de columnas S/E 5 | 2d | 2020-12-28 | 2020-12-30 | 214 | 2020-12-28 | 2020-12-30 | 2d | 65.69d | 0d |  |
| 216 | 1.5.1.14.5 | Fundida de Vigas de Cimentación S/E 5 | 1d | 2020-12-30 | 2020-12-31 | 215 | 2020-12-30 | 2020-12-31 | 1d | 65.69d |  |  |
| 217 | 1.5.1.14.6 | Armado de Columnas S/E 5 | 2d | 2020-12-23 | 2020-12-26 | 212 | 2020-12-23 | 2020-12-26 | 2d | 62.69d | 0d |  |
| 218 | 1.5.1.14.7 | Fundida de Columnas S/E 5 | 1d | 2020-12-26 | 2020-12-28 | 217 | 2020-12-26 | 2020-12-28 | 1d | 62.69d | 0d |  |
| 219 | 1.5.1.14.8 | Armado de placa y vigas Aéreas S/E 5 | 3d | 2020-12-28 | 2020-12-31 | 218 | 2020-12-28 | 2020-12-31 | 3d | 62.69d | 0d |  |
| 220 | 1.5.1.14.9 | Fundida de Placas y vigas Aéreas S/E 5 | 1d | 2020-12-31 | 2021-01-02 | 219 | 2020-12-31 | 2021-01-02 | 1d | 62.69d | 0d |  |
| 221 | 1.5.1.14.10 | Levante de muros e instalación de puertas | 2d | 2021-01-02 | 2021-01-05 | 220 | 2021-01-02 | 2021-01-05 | 2d | 62.69d |  |  |

| ID | WBS | Task | Duration | Start | Finish | Predecessors | Complete | Remaining | Baseline start | Baseline finish | Baseline duration | Total slack | Free slack | Constraint |
| --- | --- | --- | --- | --- | --- | --- | --- | --- | --- | --- | --- | --- | --- | --- |
| 222 | 1.5.2 | **EQUIPOS** | 91d | 2020-12-10 | 2021-04-03 |  |  |  | 2020-10-15 | 2021-02-04 | 91d | 0d |  |  |
| 223 | 1.5.2.1 | Compra de equipos | 1d | 2020-12-10 | 2020-12-10 |  |  |  | 2020-10-15 | 2020-10-16 | 1d | 0d |  | start no earlier than 2020-12-09 |
| 224 | 1.5.2.2 | Llegada de equipos | 55d | 2020-12-10 | 2021-02-17 | 223 |  |  | 2020-10-16 | 2020-12-22 | 55d | 0d |  | start no earlier than 2020-12-09 |
| 225 | 1.5.2.3 | Instalación | 3d | 2021-03-26 | 2021-03-30 | 224FS+30d |  |  | 2021-01-29 | 2021-02-02 | 3d | 0d |  |  |
| 226 | 1.5.2.4 | Conexionado | 2d | 2021-03-30 | 2021-04-03 | 225 |  |  | 2021-02-02 | 2021-02-04 | 2d | 0d |  |  |
| 227 | 2 | **SISTEMA DE APANTALLAMIENTO Y PUESTA A TIERRA** | 83d | 2020-11-30 A | 2021-03-12 |  | 21% | 65.86d | 2020-11-30 | 2021-03-12 | 83d | 15.81d |  |  |
| 228 | 2.1 | Excavaciones para puesta a tierra | 83d | 2020-11-30 A | 2021-03-12 |  | 25% | 62.25d | 2020-11-30 | 2021-03-12 | 83d | 15.81d | 0d | start no earlier than 2020-11-30 |
| 229 | 2.2 | Instalación de anillo de puesta a tierra | 83d | 2020-11-30 A | 2021-03-12 | 228SS | 25% | 62.25d | 2020-11-30 | 2021-03-12 | 83d | 15.81d |  |  |
| 230 | 2.3 | Instalación de malla de puesta a tierra | 8d | 2021-01-05 | 2021-01-15 | 9, 132, 133, 164, 211 |  |  | 2021-01-05 | 2021-01-15 | 8d | 62.69d |  |  |
| 231 | 2.4 | Instalación de apantallamiento | 27d | 2021-01-05 | 2021-02-06 |  |  |  | 2021-01-05 | 2021-02-06 | 27d | 44.25d |  | start no earlier than 2021-01-05 |
| 232 | 3 | **ILUMINACIÓN EXTERIOR** | 22d | 2021-02-12 | 2021-03-10 |  |  |  | 2021-02-12 | 2021-03-10 | 22d | 17.62d |  |  |
| 233 | 3.1 | Cableado | 22d | 2021-02-12 | 2021-03-10 | 50, 131, 162, 209 |  |  | 2021-02-12 | 2021-03-10 | 22d | 17.62d | 0d | start no earlier than 2021-01-18 |
| 234 | 3.2 | Instalación de luminarias | 22d | 2021-02-12 | 2021-03-10 | 233SS |  |  | 2021-02-12 | 2021-03-10 | 22d | 17.62d |  |  |
| 235 | 4 | **COMUNICACIONES** | 105.12d | 2020-10-24 A | 2021-03-02 |  | 21% | 83.49d | 2020-10-24 | 2021-02-24 | 99.44d | 33d |  |  |
| 236 | 4.1 | **Excavaciones** | 105.12d | 2020-10-24 A | 2021-03-02 |  | 23% | 80.87d | 2020-10-24 | 2021-02-24 | 99.44d | 33d |  |  |
| 237 | 4.1.1 | Apertura zanja | 75d | 2020-10-24 A | 2021-02-13 |  | 30% | 52.5d | 2020-10-24 | 2021-01-26 | 75d | 47.5d | 0d | start no earlier than 2020-10-24 |
| 238 | 4.1.2 | Adecuación zanja | 55d | 2020-10-24 A | 2021-01-28 | 237SS | 30% | 38.5d | 2020-10-24 | 2020-12-31 | 55d | 61.5d | 0d |  |
| 239 | 4.1.3 | Instalación de tubería | 78d | 2020-10-24 A | 2021-02-16 | 238SS | 30% | 54.6d | 2020-10-24 | 2021-01-29 | 78d | 0d |  |  |
| 240 | 4.1.4 | Tape zanja MT | 15d | 2021-01-29 A | 2021-03-01 | 239 | 30% | 10.5d | 2021-01-29 | 2021-02-16 | 15d | 34.9d |  |  |
| 241 | 4.1.5 | Cajas de inspección | 67d | 2020-12-10 | 2021-03-02 |  |  |  | 2020-12-02 | 2021-02-24 | 67d | 33d |  | start no earlier than 2020-12-09 |
| 242 | 4.2 | **Cableado** | 20d | 2021-01-14 | 2021-02-06 |  |  |  | 2021-01-14 | 2021-02-06 | 20d | 45.25d | 44.25d |  |
| 243 | 4.2.1 | Cableado | 15d | 2021-01-14 | 2021-02-01 |  |  |  | 2021-01-14 | 2021-02-01 | 15d | 45.25d | 0d | start no earlier than 2021-01-14 |
| 244 | 4.2.2 | Conexionado | 5d | 2021-02-01 | 2021-02-06 | 243 |  |  | 2021-02-01 | 2021-02-06 | 5d | 45.25d |  |  |
| 245 | 4.3 | **Detección de incendio** | 8d | 2021-01-21 | 2021-01-30 |  |  |  | 2021-01-21 | 2021-01-30 | 8d | 59.31d |  |  |
| 246 | 4.3.1 | Instalación de tubería | 6d | 2021-01-21 | 2021-01-28 |  |  |  | 2021-01-21 | 2021-01-28 | 6d | 59.31d | 0d | start no earlier than 2021-01-21 |
| 247 | 4.3.2 | Cableado | 2d | 2021-01-28 | 2021-01-30 | 246 |  |  | 2021-01-28 | 2021-01-30 | 2d | 59.31d |  |  |

Notes:
- 241: Se presentan atrasos por definición en adecuación de terreno, para cimentación de cajas de inspección.

| ID | WBS | Task | Duration | Start | Finish | Predecessors | Baseline start | Baseline finish | Baseline duration | Total slack | Free slack | Constraint |
| --- | --- | --- | --- | --- | --- | --- | --- | --- | --- | --- | --- | --- |
| 248 | 4.4 | **Sistema de control** | 7d | 2021-02-03 | 2021-02-11 |  | 2021-02-03 | 2021-02-11 | 7d | 49.5d |  |  |
| 249 | 4.4.1 | Instalación de tubería | 5d | 2021-02-03 | 2021-02-09 |  | 2021-02-03 | 2021-02-09 | 5d | 49.5d | 0d | start no earlier than 2021-02-03 |
| 250 | 4.4.2 | Cableado | 2d | 2021-02-09 | 2021-02-11 | 249 | 2021-02-09 | 2021-02-11 | 2d | 49.5d |  |  |
| 251 | 5 | **CERTIFICACIONES RETIE Y RETILAP** | 8d | 2021-04-03 | 2021-04-13 |  | 2021-03-12 | 2021-03-23 | 8d | 0d |  |  |
| 252 | 5.1 | Visita de inspección Retie | 2d | 2021-04-03 | 2021-04-06 | 1, 227, 232 | 2021-03-12 | 2021-03-15 | 2d | 0d |  |  |
| 253 | 5.2 | Visita de inspección Retilap | 1d | 2021-04-03 | 2021-04-05 | 1, 227, 232, 242 | 2021-03-12 | 2021-03-13 | 1d | 1d | 0d |  |
| 254 | 5.3 | Entrega de certificación Retie | 1d | 2021-04-12 | 2021-04-13 | 252FS+5d | 2021-03-20 | 2021-03-23 | 1d | 0d |  |  |
| 255 | 5.4 | Entrega de certificación Retilap | 1d | 2021-04-10 | 2021-04-12 | 253FS+5d | 2021-03-19 | 2021-03-20 | 1d | 1d |  |  |
| 256 | 6 | **ENERGIZACIÓN** | 1d? | 2021-04-13 | 2021-04-14 |  | 2021-03-23 | 2021-03-24 | 1d? | 0d |  |  |
| 257 | 6.1 | Entrega del proyecto | 1d? | 2021-04-13 | 2021-04-14 | 1, 227, 251 | 2021-03-23 | 2021-03-24 | 1d? | 0d |  |  |
